Schedule from Planner, 2008-06-23 to 2008-08-19.

## Calendars

- Default: Mon-Fri 08:00-12:00, 13:00-17:00; Sat-Sun off.

## Resources

| Resource |
| --- |
| Robert Cruikshank |
| Ian Grigg |
| Teus Hagen |
| Jacco de Leeuw |
| Ruud Kenbeek |
| Marco Hermans |
| Wolfgang Nagele |
| Mendel Mobach |
| Brenno de Winter |
| Wytze van de Raay |
| Philipp Gühring |

## Schedule

| ID | WBS | Task | Type | Duration | Start | Finish | Predecessors | Constraint | Resources | Work |
| --- | --- | --- | --- | --- | --- | --- | --- | --- | --- | --- |
| 1 | 1 | Start | milestone | 0d | 2008-06-23 | 2008-06-23 |  |  |  |  |
| 2 | 2 | **Prepare resources for Ede work** |  | 18.88d | 2008-06-23 | 2008-07-17 | 1 |  |  | 309.35h |
| 3 | 2.1 | Obtain detailed commitment from Ede Admin people |  | 15d | 2008-06-23 | 2008-07-10 |  |  | Teus Hagen [33%]; Brenno de Winter [33%]; Wytze van de Raay [33%]; Philipp Gühring [33%] | 159.35h |
| 4 | 2.2 | Document server configurations and admin tasks for move and setup in Ede |  | 15d | 2008-06-23 | 2008-07-10 | 1 |  | Philipp Gühring [50%] | 60h |
| 5 | 2.3 | Test USB Signing server protocol in Vienna |  | 5d | 2008-07-07 | 2008-07-11 | 1 | start no earlier than 2008-07-07 | Philipp Gühring [25%] | 10h |
| 6 | 2.4 | Prepare rack space and network requirements in Ede |  | 5d | 2008-07-11 | 2008-07-17 | 4, 3, 5 |  | Teus Hagen [67%]; Brenno de Winter [67%]; Wytze van de Raay [67%] | 80h |
| 7 | 3 | **Purchase new servers for Ede?** |  | 8.88d | 2008-07-10 | 2008-07-23 | 4 |  |  | 84h |
| 8 | 3.1 | Source supplier |  | 1d | 2008-07-10 | 2008-07-11 |  |  | Teus Hagen | 8h |
| 9 | 3.2 | Develop H/W Specification |  | 1d | 2008-07-11 | 2008-07-14 | 8 |  | Philipp Gühring [50%] | 4h |
| 10 | 3.3 | Confirm with Supplier and obtain quote |  | 1d | 2008-07-14 | 2008-07-14 | 9 |  | Teus Hagen | 8h |
| 11 | 3.4 | Gain Funds approval |  | 1d | 2008-07-15 | 2008-07-15 | 10 |  | Robert Cruikshank; Teus Hagen | 16h |
| 12 | 3.5 | Transfer funds from AU to NL |  | 4d | 2008-07-15 | 2008-07-21 | 11 |  | Robert Cruikshank | 32h |
| 13 | 3.6 | Ship servers from Supplier to Ede |  | 2d | 2008-07-21 | 2008-07-23 | 12 |  | Teus Hagen | 16h |
| 14 | 4 | **Train and handover detailed admin knowledge to Ede Admin people** |  | 3.5d | 2008-07-23 | 2008-07-28 | 7 |  |  | 80h |
| 15 | 4.1 | Get Philipp to NL |  | 1d | 2008-07-23 | 2008-07-24 |  |  | Philipp Gühring | 8h |
| 16 | 4.2 | Technology Introduction |  | 3d | 2008-07-24 | 2008-07-28 | 15 |  | Brenno de Winter; Wytze van de Raay; Philipp Gühring | 72h |
| 17 | 5 | **Setup new critical servers** |  | 9.75d | 2008-07-28 | 2008-08-11 | 14, 6 |  |  | 265h |
| 18 | 5.1 | Install OS |  | 1d | 2008-07-28 | 2008-07-29 |  |  | Brenno de Winter; Wytze van de Raay; Philipp Gühring | 24h |
| 19 | 5.2 | Install applications |  | 2d | 2008-07-29 | 2008-07-31 | 18 |  | Brenno de Winter; Wytze van de Raay; Philipp Gühring | 48h |
| 20 | 5.3 | Harden OS |  | 2d | 2008-07-31 | 2008-08-04 | 19 |  | Brenno de Winter; Wytze van de Raay; Philipp Gühring | 48h |
| 21 | 5.4 | Install USB Signing Server protocol and test |  | 1d | 2008-08-04 | 2008-08-05 | 20 |  | Brenno de Winter; Wytze van de Raay; Philipp Gühring | 24h |
| 22 | 5.5 | Test new server with dummy data |  | 5d | 2008-08-05 | 2008-08-11 | 21 |  | Brenno de Winter; Wytze van de Raay; Philipp Gühring | 120h |
| 23 | 5.6 | Reduce TTL for www.cacert.org |  | 0.12d | 2008-07-29 | 2008-07-29 | 18 |  | Philipp Gühring | 1h |
| 24 | 6 | **Test new servers and switchover** |  | 4.5d | 2008-08-11 | 2008-08-15 | 17 |  |  | 120h |
| 25 | 6.1 | Test functionality |  | 2d | 2008-08-11 | 2008-08-13 |  |  | Brenno de Winter; Wytze van de Raay; Philipp Gühring | 48h |
| 26 | 6.2 | Migrate data securely to Ede |  | 2d | 2008-08-13 | 2008-08-15 | 25 |  | Brenno de Winter; Wytze van de Raay; Philipp Gühring | 48h |
| 27 | 6.3 | Redirect domain name to Ede |  | 1d | 2008-08-15 | 2008-08-15 | 26 |  | Brenno de Winter; Wytze van de Raay; Philipp Gühring | 24h |
| 28 | 7 | CAcert live from Ede | milestone | 0d | 2008-08-15 | 2008-08-15 | 24 |  |  |  |

| ID | WBS | Task | Type | Duration | Start | Finish | Predecessors | Resources | Work |
| --- | --- | --- | --- | --- | --- | --- | --- | --- | --- |
| 29 | 8 | **Root Key Correction** |  | 1.75d | 2008-08-18 | 2008-08-19 | 28 |  | 96h |
| 30 | 8.1 | Install root key (controlled by audit, Oophaga & CAcert) |  | 1d | 2008-08-18 | 2008-08-18 |  | Ian Grigg; Teus Hagen; Ruud Kenbeek; Brenno de Winter; Wytze van de Raay; Philipp Gühring | 48h |
| 31 | 8.2 | Evaluation of critical systems operation |  | 1d | 2008-08-18 | 2008-08-19 | 30 | Ian Grigg; Teus Hagen; Ruud Kenbeek; Brenno de Winter; Wytze van de Raay; Philipp Gühring | 48h |
| 32 | 9 | End | milestone | 0d | 2008-08-19 | 2008-08-19 | 29 |  |  |
